# ASIC Program Resources

Schedule from MS Project, 2018-01-01 to 2023-03-31, A marks actual dates.

## Calendars

- Standard: Mon-Fri 08:00-12:00, 13:00-17:00; Sat-Sun off.

## Resources

| Resource |
| --- |
| G. Deptuch |
| F. Fahim |
| D. Braga |
| S. Miryala |
| T. Zimmerman |
| J. Hoff |
| A. Shenai |
| S. Holm |
| Student 1 |
| Student 2 |
| Student 3 |
| L. DalMonte |
| R. Wickwire |
| P. Rubinov |
| J. Hirschauer |
| N. Moibenko |
| A. Dyer |
| P. Klabbers |
| J. Olsen |
| Q. Sun |
| J. Wu |
| M. Hammer |
| Not Assigned |
| M. Noy |
| C. Gingu |

## Schedule

| ID | WBS | Task | Type | Duration | Start | Finish | Predecessors | Complete | Remaining | Actual start | Baseline start | Baseline finish | Baseline duration | Resources | Work | Actual work | FTE | Comment |
| --- | --- | --- | --- | --- | --- | --- | --- | --- | --- | --- | --- | --- | --- | --- | --- | --- | --- | --- |
| 1 | 1 | **Cold Electronics (DUNE)** |  | 782d | 2018-06-04 A | 2021-06-01 |  | 41% | 457.67d |  | 2018-06-04 | 2020-12-09 | 0d |  | 9598.8h | 5713.2h | 3.7 |  |
| 2 | 1.1 | **ColdADC** |  | 483d | 2018-06-04 A | 2020-04-08 |  | 60% | 192.1d |  | 2018-06-04 | 2020-04-08 | 0d |  | 4352.8h | 3062.8h |  |  |
| 3 | 1.1.1 | **Version 1** |  | 253d | 2018-06-04 A | 2019-05-22 |  | 99% | 0d |  | 2018-06-04 | 2019-05-22 | 0d |  | 3062.8h | 3062.8h |  | All at 100% (for FNAL?) |
| 4 | 1.1.1.1 | CADC V1 Start | milestone | 0d | 2018-06-04 A | 2018-06-04 A |  | 100% |  |  | 2018-06-04 | 2018-06-04 | 0d |  |  |  |  |  |
| 5 | 1.1.1.2 | CADC V1 Design | manual | 108d | 2018-06-04 A | 2018-10-31 A | 4 | 100% |  |  | 2018-06-04 | 2018-10-31 | 0d | D. Braga [90%]; J. Hoff [80%]; S. Miryala [50%] | 1900.8h | 1900.8h |  |  |
| 6 | 1.1.1.3 | CADC V1 Simulation and Scripts | manual | 108d | 2018-06-04 A | 2018-10-31 A | 4 | 100% |  |  | 2018-06-04 | 2018-10-31 | 0d | A. Shenai [35%] | 302.4h | 302.4h |  |  |
| 7 | 1.1.1.4 | CADC V1 Submission | milestone | 0d | 2018-10-31 A | 2018-10-31 A | 5, 6 | 100% |  |  | 2018-10-31 | 2018-10-31 | 0d |  |  |  |  |  |
| 8 | 1.1.1.5 | CADC V1 Fab | manual | 68d | 2018-10-31 A | 2019-02-01 A | 7 | 100% |  |  | 2018-10-31 | 2019-03-01 | 0d |  |  |  |  |  |
| 9 | 1.1.1.6 | CADC V1 Design & Fab Test Board | manual | 41d | 2018-11-05 A | 2018-12-31 A | 7 | 100% |  |  | 2018-11-05 | 2018-12-31 | 0d | S. Holm [50%]; N. Moibenko [50%]; A. Dyer [5%] | 344.4h | 344.4h |  |  |
| 10 | 1.1.1.7 | CADC V1 Test | manual | 46d | 2019-02-04 A | 2019-04-08 A | 8, 9 | 100% |  |  | 2019-03-04 | 2019-05-02 | 0d | S. Holm [70%]; L. DalMonte [70%] | 515.2h | 515.2h |  | FNAL work done |
| 11 | 1.1.1.8 | CADC V1 Complete | milestone, manual | 0d | 2019-04-09 | 2019-04-09 | 10 |  |  |  | 2019-05-03 | 2019-05-03 | 0d |  |  |  |  | Ditto |
| 12 | 1.1.2 | **Version 2** |  | 180d | 2020-01-06 | 2020-09-11 |  |  |  |  | 2020-01-06 | 2020-09-11 | 0d |  | 1290h |  |  |  |
| 13 | 1.1.2.1 | CADC V2 Start | milestone, manual | 0d | 2020-01-06 | 2020-01-06 | 11 |  |  |  | 2020-01-06 | 2020-01-06 | 0d |  |  |  |  |  |
| 14 | 1.1.2.2 | CADC V2 Design | manual | 65d | 2020-01-06 | 2020-04-03 | 13 |  |  |  | 2020-01-06 | 2020-04-03 | 0d | D. Braga [50%]; J. Hoff [20%]; S. Miryala [70%] | 728h |  |  |  |
| 15 | 1.1.2.3 | CADC V2 Simulation and Scripts | manual | 65d | 2020-01-06 | 2020-04-03 | 13 |  |  |  | 2020-01-06 | 2020-04-03 | 0d | A. Shenai [35%] | 152h |  |  |  |
| 16 | 1.1.2.4 | CADC V2 Submission | milestone, manual | 0d | 2020-04-06 | 2020-04-06 | 14, 15 |  |  |  | 2020-04-06 | 2020-04-06 | 0d |  |  |  |  |  |
| 17 | 1.1.2.5 | CADC V2 Fab | manual | 70d | 2020-04-06 | 2020-07-10 | 16 |  |  |  | 2020-04-06 | 2020-07-10 | 0d |  |  |  |  |  |
| 18 | 1.1.2.6 | CADC V2 Design & Fab Test Board | manual | 25d | 2020-04-06 | 2020-05-08 | 17 |  |  |  | 2020-04-06 | 2020-05-08 | 0d | S. Holm [40%]; L. DalMonte [40%]; A. Dyer [5%] | 186h |  |  |  |
| 19 | 1.1.2.7 | CADC V2 Test | manual | 20d | 2020-07-13 | 2020-08-07 | 17, 18 |  |  |  | 2020-07-13 | 2020-08-07 | 0d | S. Holm [70%]; L. DalMonte [70%] | 224h |  |  |  |
| 20 | 1.1.2.8 | CADC V2 Complete | milestone, manual | 0d | 2020-08-07 | 2020-08-07 | 19 |  |  |  | 2020-08-07 | 2020-08-07 | 0d |  |  |  |  |  |
| 21 | 1.2 | **ColData** |  | 509d | 2018-07-01 A | 2020-06-10 |  | 50% | 256.1d |  | 2018-07-01 | 2020-06-10 | 0d |  | 4122.8h | 2650.4h |  |  |
| 22 | 1.2.1 | **Version 1** |  | 294d | 2018-07-01 | 2019-08-14 |  | 90% | 30.82d | 2018-10-31 | 2018-07-01 | 2019-08-14 | 0d |  | 2946.8h | 2650.4h |  |  |
| 23 | 1.2.1.1 | CData V1 Start (Follows ColdADC) | milestone | 0d | 2018-10-31 A | 2018-10-31 A | 5, 6 | 100% |  |  | 2018-10-31 | 2018-10-31 | 0d |  |  |  |  |  |
| 24 | 1.2.1.2 | CData V1 Design | manual | 133d | 2018-11-01 A | 2019-05-06 A | 23 | 100% |  |  | 2018-11-01 | 2019-02-19 | 0d | D. Braga [50%]; J. Hoff [80%]; S. Miryala [60%] | 2128h | 2128h |  | Adjusted to ~PMG numbers |
| 25 | 1.2.1.3 | CData V1 Simulation and Scripts | manual | 133d | 2018-11-01 A | 2019-05-06 A | 23 | 100% |  |  | 2018-11-01 | 2019-02-19 | 0d | A. Shenai [15%] | 372.4h | 372.4h |  | Adjusted to ~PMG numbers |
| 26 | 1.2.1.4 | CData V1 Submission | milestone, manual | 0d | 2019-05-06 A | 2019-05-06 A | 24, 25 | 100% |  |  | 2019-02-20 | 2019-02-20 | 0d |  |  |  |  |  |
| 27 | 1.2.1.5 | CData V1 Fab | manual | 41d | 2019-05-06 A | 2019-07-01 A | 25, 24 | 100% |  |  | 2019-03-20 | 2019-06-19 | 0d |  |  |  |  |  |
| 28 | 1.2.1.6 | CData V1 Test PCBs | manual | 16d | 2019-02-21 A | 2019-03-14 A |  | 100% |  |  | 2019-02-21 | 2019-03-14 | 0d | S. Holm [50%]; N. Moibenko [50%]; A. Dyer [5%] | 134.4h | 134.4h |  |  |
| 29 | 1.2.1.7 | CData V1 Test | manual | 39d | 2019-06-20 A | 2019-08-13 | 27 | 5% | 37.05d |  | 2019-06-20 | 2019-08-14 | 0d | L. DalMonte [50%]; S. Holm [50%] | 312h | 15.6h |  |  |
| 30 | 1.2.1.8 | CData V1 Complete | manual | 1d | 2019-08-14 | 2019-08-14 | 29 |  |  |  | 2019-08-14 | 2019-08-14 | 0d |  |  |  |  |  |

| ID | WBS | Task | Type | Duration | Start | Finish | Predecessors | Complete | Remaining | Actual start | Actual finish | Baseline start | Baseline finish | Baseline duration | Total slack | Resources | Work | Actual work | Comment | FTE |
| --- | --- | --- | --- | --- | --- | --- | --- | --- | --- | --- | --- | --- | --- | --- | --- | --- | --- | --- | --- | --- |
| 31 | 1.2.2 | **Version 2 (no Combined)** |  | 165d | 2020-04-06 | 2020-11-20 |  |  |  |  |  | 2019-10-21 | 2020-11-20 | 0d |  |  | 1176h |  | May not be needed |  |
| 32 | 1.2.2.1 | CData V2 Design | manual | 60d | 2020-04-06 | 2020-06-26 | 14 |  |  |  |  | 2020-04-06 | 2020-06-26 | 0d |  | D. Braga [50%]; J. Hoff [50%]; S. Miryala [50%] | 720h |  |  |  |
| 33 | 1.2.2.2 | CData V2 Simulation and Scripts | manual | 60d | 2020-04-06 | 2020-06-26 | 15 |  |  |  |  | 2020-04-06 | 2020-06-26 | 0d |  | A. Shenai [25%] | 120h |  |  |  |
| 34 | 1.2.2.3 | CData V2 Submission | milestone, manual | 0d | 2020-06-29 | 2020-06-29 | 32, 33 |  |  |  |  | 2020-06-29 | 2020-06-29 | 0d |  |  |  |  |  |  |
| 35 | 1.2.2.4 | CData V2 Fab | manual | 66d | 2020-06-29 | 2020-09-28 | 32, 33 |  |  |  |  | 2020-06-29 | 2020-09-28 | 0d |  |  |  |  |  |  |
| 36 | 1.2.2.5 | CData V2 Test & New PCB | manual | 105d | 2020-06-29 | 2020-11-20 | 35 |  |  |  |  | 2020-06-29 | 2020-11-20 | 0d |  | S. Holm [30%]; L. DalMonte [30%]; A. Dyer [5%] | 336h |  |  |  |
| 37 | 1.3 | **Combined ASIC (no ColData V2)** |  | 181d | 2019-07-01 | 2020-03-09 |  |  |  |  |  | 2019-07-01 | 2020-03-09 | 0d |  |  |  |  |  |  |
| 38 | 1.3.1 | ColdComb Design | manual | 71d | 2019-07-01 | 2019-10-07 | 14 |  |  |  |  | 2019-07-01 | 2019-10-07 | 0d |  |  |  |  |  |  |
| 39 | 1.3.2 | ColdComb Simulation and Scripts | manual | 41d | 2019-07-01 | 2019-08-26 | 15 |  |  |  |  | 2019-07-01 | 2019-08-26 | 0d |  |  |  |  |  |  |
| 40 | 1.3.3 | ColdComb Fab | manual | 66d | 2019-10-07 | 2020-01-06 | 38, 39 |  |  |  |  | 2019-10-07 | 2020-01-06 | 0d |  |  |  |  |  |  |
| 41 | 1.3.4 | ColdComb Test | manual | 46d | 2020-01-06 | 2020-03-09 | 40 |  |  |  |  | 2020-01-06 | 2020-03-09 | 0d |  |  |  |  |  |  |
| 42 | 1.4 | **Prepare for Engineering Run** |  | 186d | 2020-06-01 | 2021-02-15 |  |  |  |  |  | 2020-06-01 | 2020-08-10 | 0d | 0d |  | 1123.2h |  |  |  |
| 43 | 1.4.1 | Prepare for Engineering Run | manual | 117d | 2020-06-01 | 2020-11-10 | 36, 41, 20 |  |  |  |  | 2020-06-01 | 2020-11-10 | 0d |  | D. Braga [50%]; J. Hoff [20%]; S. Miryala [50%] | 1123.2h |  | Later? |  |
| 44 | 1.4.2 | Engineering Fab Run | manual | 67d | 2020-11-13 | 2021-02-15 | 43 |  |  |  |  | 2020-11-13 | 2021-02-15 | 0d |  |  |  |  |  |  |
| 45 | 1.5 | DUNE APA Construction (arb. Date) | milestone, manual | 0d | 2021-06-01 | 2021-06-01 | 44 |  |  |  |  | 2020-07-06 | 2020-07-06 | 0d |  |  |  |  |  |  |
| 47 | 2 | **ECON (CMS HGCAL)** |  | 1021d? | 2018-08-13 A | 2022-07-11 |  | 3% | 989.98d? |  |  | 2018-08-13 | 2022-07-11 | 0d |  |  | 15386h | 108h |  | 7.6 |
| 48 | 2.1 | ECON HGC Readout System Architecture | manual | 176d | 2019-01-01 | 2019-09-03 |  |  |  |  |  | 2019-01-01 | 2019-09-03 | 0d |  | G. Deptuch [25%]; M. Noy [90%] | 1619.2h |  |  |  |
| 49 | 2.2 | **ECON Preliminary** |  | 490d? | 2018-08-13 | 2020-06-26 |  | 3% | 476.96d? | 2018-09-05 |  | 2018-08-13 | 2020-06-26 | 0d |  |  | 328h | 108h |  |  |
| 50 | 2.2.1 | **lpGBT** |  | 188d | 2018-09-05 A | 2019-05-24 |  | 100% |  |  | 2018-09-28 | 2018-09-05 | 2019-05-24 | 0d |  |  | 108h | 108h |  |  |
| 51 | 2.2.1.1 | ECON1 lpGBT IP Transfer | milestone, manual | 0d | 2018-09-05 A | 2018-09-05 A | 56 | 100% |  |  |  | 2018-09-05 | 2018-09-05 | 0d |  | G. Deptuch [90%]; J. Hoff [90%]; S. Miryala [90%] |  |  |  |  |
| 52 | 2.2.1.2 | ECON 1 Fermi @ CERN (IP Transfer) | manual | 5d | 2018-09-24 A | 2018-09-28 A | 51 | 100% |  |  |  | 2018-09-24 | 2018-09-28 | 0d |  | G. Deptuch [90%]; J. Hoff [90%]; S. Miryala [90%] | 108h | 108h |  |  |
| 53 | 2.2.2 | ECON Prototype 1 Specification | manual | 55d | 2018-10-01 | 2018-12-14 | 56, 52 |  |  |  |  | 2018-10-01 | 2018-12-14 | 0d |  | G. Deptuch [50%] | 220h |  | Is this complete? When? |  |
| 54 | 2.2.3 | lpGBT Database analysis | manual | 205d | 2019-01-07 A | 2019-10-18 |  | 1% | 202.95d |  |  | 2019-01-07 | 2019-10-18 | 0d |  |  |  |  |  |  |
| 55 | 2.3 | **ECON 1** |  | 260d? | 2019-06-03 | 2020-05-29 |  | 4% | 248.41d? | 2018-09-24 |  | 2019-06-03 | 2020-05-29 | 0d |  |  | 8462.8h |  | Chose a median date from Jim's slide 10 |  |
| 56 | 2.3.1 | ECON V1 Start | manual | 1d | 2019-06-03 A | 2019-06-03 A |  | 100% |  |  |  | 2019-06-03 | 2019-06-03 | 0d |  |  |  |  |  |  |

| ID | WBS | Task | Type | Duration | Start | Finish | Predecessors | Complete | Remaining | Actual start | Baseline start | Baseline finish | Baseline duration | Constraint | Resources | Work | Comment |
| --- | --- | --- | --- | --- | --- | --- | --- | --- | --- | --- | --- | --- | --- | --- | --- | --- | --- |
| 57 | 2.3.2 | **ECON 1 Design** |  | 260d? | 2019-06-03 | 2020-05-29 |  | 6% | 244.4d? | 2018-09-24 | 2019-06-03 | 2020-05-29 | 0d |  |  | 6982h |  |
| 58 | 2.3.2.1 | ECON 1 Design | manual | 345d? | 2019-02-04 | 2020-05-29 |  |  |  |  | 2019-06-03 | 2020-05-29 | 0d | start no earlier than 2019-02-04 | G. Deptuch [10%]; R. Wickwire [90%]; M. Hammer [60%]; A. Shenai [30%]; D. Braga [25%]; F. Fahim [10%]; J. Hoff [25%]; S. Miryala [25%]; C. Gingu [20%] | 6682h |  |
| 59 | 2.3.2.2 | **ePort RX** |  | 155d | 2019-06-03 A | 2020-01-03 |  | 17% | 129.32d |  | 2019-06-03 | 2020-01-03 | 0d |  |  |  | Who? |
| 60 | 2.3.2.2.1 | E1 ePort Block Level | manual | 25d | 2019-06-03 A | 2019-07-05 |  | 55% | 11.25d |  | 2019-06-03 | 2019-08-09 | 0d |  |  |  | <0.5 wk |
| 61 | 2.3.2.2.2 | E1 ePort Block Level | manual | 21d | 2019-08-12 A | 2019-09-09 | 60 | 30% | 14.7d |  | 2019-08-12 | 2019-09-20 | 0d |  |  |  | < 4.1 wk |
| 62 | 2.3.2.2.3 | E1 ePort Chip Level | manual | 75d | 2019-09-23 | 2020-01-03 | 61 |  |  |  | 2019-09-23 | 2020-01-03 | 0d |  |  |  | <15.5 wk |
| 63 | 2.3.2.3 | **Aligner** |  | 120d | 2019-06-03 | 2019-11-15 |  | 48% | 63d | 2019-05-27 | 2019-06-03 | 2019-11-15 | 0d |  |  |  |  |
| 64 | 2.3.2.3.1 | E1 Align def/verilog/sim | manual | 5d | 2019-05-27 A | 2019-05-31 A |  | 100% |  |  | 2019-05-27 | 2019-05-31 | 0d |  |  |  |  |
| 65 | 2.3.2.3.2 | E1 Align Block Level | manual | 5d | 2019-08-26 A | 2019-08-30 | 64 | 90% | 0.5d |  | 2019-08-26 | 2019-09-06 | 0d |  |  |  | 0.3 wk |
| 66 | 2.3.2.3.3 | E1 Align Chip Level | manual | 10d | 2019-09-09 | 2019-09-20 | 65 |  |  |  | 2019-09-09 | 2019-09-20 | 0d |  |  |  | <6.9 wk |
| 67 | 2.3.2.4 | First Chiplet | milestone, manual | 0d | 2019-12-27 | 2019-12-27 |  |  |  |  |  |  |  |  |  |  | Arbitrary Date |
| 68 | 2.3.2.5 | **Data Mux** |  | 135d | 2019-06-03 | 2019-12-06 |  | 29% | 96.26d | 2019-05-27 | 2019-06-03 | 2019-12-06 | 0d |  |  |  |  |
| 69 | 2.3.2.5.1 | E1 Mux def/verilog/sim | manual | 5d | 2019-05-27 A | 2019-05-31 A |  | 100% |  |  | 2019-05-27 | 2019-05-31 | 0d |  |  |  |  |
| 70 | 2.3.2.5.2 | E1 Mux Block Level | manual | 8d | 2019-08-05 A | 2019-08-14 | 69 | 20% | 6.4d |  | 2019-08-05 | 2019-08-16 | 0d |  |  |  | <1.7 wk |
| 71 | 2.3.2.5.3 | E1 Mux Chip Level | manual | 10d | 2019-08-19 | 2019-08-30 | 70 |  |  |  | 2019-08-19 | 2019-08-30 | 0d |  |  |  | <3.6 wk |
| 72 | 2.3.2.6 | Second Chiplet | milestone, manual | 0d | 2020-01-31 | 2020-01-31 |  |  |  |  |  |  |  |  |  |  | Arbitrary Date |
| 73 | 2.3.2.7 | **Fast Command** |  | 90d | 2019-06-03 | 2019-10-04 |  |  |  |  | 2019-01-07 | 2019-05-10 | 0d |  |  |  |  |
| 74 | 2.3.2.7.1 | E1 Fast Cmd def/verilog/sim | manual | 35d | 2019-06-03 | 2019-07-19 |  |  |  |  | 2019-06-03 | 2019-07-19 | 0d |  |  |  | 0.2 wk |
| 75 | 2.3.2.7.2 | E1 Fast Cmd Block Level | manual | 10d | 2019-07-22 | 2019-08-02 | 74 |  |  |  | 2019-07-22 | 2019-08-02 | 0d |  |  |  | 0.6 wk |
| 76 | 2.3.2.7.3 | E1 Fast Cmd Chip Level | manual | 10d | 2019-08-05 | 2019-08-16 | 75 |  |  |  | 2019-08-05 | 2019-08-16 | 0d |  |  |  | <3.5 wk |
| 77 | 2.3.2.8 | **Error Handling** |  | 75d | 2019-06-03 A | 2019-09-13 |  | 27% | 54.5d |  | 2019-02-04 | 2019-05-17 | 0d |  |  |  |  |
| 78 | 2.3.2.8.1 | E1 Error Hand def/verilog/sim | manual | 17.5d | 2019-06-03 A | 2019-06-26 |  | 50% | 8.75d |  | 2019-06-03 | 2019-07-05 | 0d |  |  |  | <3.2 wk |
| 79 | 2.3.2.8.2 | E1 Error Hand Block Level | manual | 10d | 2019-07-08 A | 2019-07-19 | 78 | 15% | 8.5d |  | 2019-07-08 | 2019-07-19 | 0d |  |  |  | <1 wk |
| 80 | 2.3.2.8.3 | E1 Error Hand Chip Level | manual | 10d | 2019-07-22 | 2019-08-02 | 79 |  |  |  | 2019-07-22 | 2019-08-02 | 0d |  |  |  | <7.8 wk |

| ID | WBS | Task | Type | Duration | Start | Finish | Predecessors | Complete | Remaining | Baseline start | Baseline finish | Baseline duration | Comment |
| --- | --- | --- | --- | --- | --- | --- | --- | --- | --- | --- | --- | --- | --- |
| 81 | 2.3.2.9 | **I2C Interface** |  | 70d | 2019-06-03 A | 2019-09-06 |  | 29% | 49.88d | 2019-02-18 | 2019-05-24 | 0d |  |
| 82 | 2.3.2.9.1 | E1 I2C def/verilog/sim | manual | 20d | 2019-06-03 A | 2019-06-28 |  | 50% | 10d | 2019-06-03 | 2019-06-28 | 0d | < 1.2 wk |
| 83 | 2.3.2.9.2 | E1 I2C Block Level | manual | 10d | 2019-07-01 A | 2019-07-12 | 82 | 15% | 8.5d | 2019-07-01 | 2019-07-12 | 0d | <1.4 wk |
| 84 | 2.3.2.9.3 | E1 I2C Chip Level | manual | 10d | 2019-07-15 | 2019-07-26 | 83 |  |  | 2019-07-15 | 2019-07-26 | 0d | <5.8 wk |
| 85 | 2.3.2.10 | **efuse** |  | 80d | 2019-06-03 | 2019-09-20 |  |  |  | 2019-01-21 | 2019-05-10 | 0d |  |
| 86 | 2.3.2.10.1 | E1 efuse def/verilog/sim | manual | 30d | 2019-06-03 | 2019-07-12 |  |  |  | 2019-06-03 | 2019-07-12 | 0d | 4.5 wk |
| 87 | 2.3.2.10.2 | E1 efuse Block Level | manual | 10d | 2019-07-15 | 2019-07-26 | 86 |  |  | 2019-07-15 | 2019-07-26 | 0d | <2.1 wk |
| 88 | 2.3.2.10.3 | E1 efuse Chip Level | manual | 10d | 2019-07-29 | 2019-08-09 | 87 |  |  | 2019-07-29 | 2019-08-09 | 0d | <4.8 wk |
| 89 | 2.3.2.11 | **PLL Calibration/EPortRX training** |  | 125d | 2019-06-03 A | 2019-11-22 |  | 38% | 77.21d | 2019-01-07 | 2019-06-28 | 0d |  |
| 90 | 2.3.2.11.1 | E1 Calib/Eport def/verilog/sim | manual | 65d | 2019-06-03 A | 2019-08-30 |  | 50% | 32.5d | 2019-06-03 | 2019-08-30 | 0d | <0.1 wk |
| 91 | 2.3.2.11.2 | E1 Calib/Eport Block Level | manual | 10d | 2019-09-02 | 2019-09-13 | 90 |  |  | 2019-09-02 | 2019-09-13 | 0d | 1 wk |
| 92 | 2.3.2.11.3 | E1 Calib/Eport Chip Level | manual | 10d | 2019-09-16 | 2019-09-27 | 91 |  |  | 2019-09-16 | 2019-09-27 | 0d |  |
| 93 | 2.3.2.12 | **eTx 1.28 Gbps digital** |  | 165d | 2019-06-03 | 2020-01-17 |  |  |  | 2019-01-07 | 2020-01-17 | 0d |  |
| 94 | 2.3.2.12.1 | E1 eTx digi def/verilog/sim | manual | 50d | 2019-06-03 | 2019-08-09 | 52 |  |  | 2019-06-03 | 2019-08-09 | 0d | <2 wk |
| 95 | 2.3.2.12.2 | E1 eTx digi Block Level | manual | 30d | 2019-08-12 | 2019-09-20 | 94 |  |  | 2019-08-12 | 2019-09-20 | 0d | 1.5 wk |
| 96 | 2.3.2.12.3 | E1 eTx digi Chip Level | manual | 35d | 2019-09-23 | 2019-11-08 | 95 |  |  | 2019-09-23 | 2019-11-08 | 0d | <2.5 wk |
| 97 | 2.3.2.13 | **eTx 1.28 Gbps analog/full custom** |  | 165d? | 2019-06-03 | 2020-01-17 |  |  |  | 2019-06-03 | 2020-01-17 | 0d |  |
| 98 | 2.3.2.13.1 | E1 eTx analog def/verilog/sim | manual | 50d? | 2019-06-03 | 2019-08-09 |  |  |  | 2019-06-03 | 2019-08-09 | 0d | 3 wk |
| 99 | 2.3.2.13.2 | E1 eTx analog Block level | manual | 30d? | 2019-08-12 | 2019-09-20 | 98 |  |  | 2019-08-12 | 2019-09-20 | 0d | <2.1 wk |
| 100 | 2.3.2.13.3 | E1 eTx analog Chip level | manual | 35d? | 2019-09-23 | 2019-11-08 | 99 |  |  | 2019-09-23 | 2019-11-08 | 0d | <2.3 wk |
| 101 | 2.3.2.14 | **Latency Control Management** |  | 130d | 2019-06-03 | 2019-11-29 |  |  |  | 2019-01-07 | 2019-07-05 | 0d |  |
| 102 | 2.3.2.14.1 | E1 Latency def/verilog/sim | manual | 40d | 2019-06-03 | 2019-07-26 |  |  |  | 2019-06-03 | 2019-07-26 | 0d | 3.4 wk |
| 103 | 2.3.2.14.2 | E1 Latency Block Level | manual | 10d | 2019-07-29 | 2019-08-09 | 102 |  |  | 2019-07-29 | 2019-08-09 | 0d | 0.3 |
| 104 | 2.3.2.14.3 | E1 Latency Verificiation | manual | 10d | 2019-08-12 | 2019-08-23 | 103 |  |  | 2019-08-12 | 2019-08-23 | 0d | <5.2 wk |

| ID | WBS | Task | Type | Duration | Start | Finish | Predecessors | Baseline start | Baseline finish | Baseline duration | Resources | Work | Comment |
| --- | --- | --- | --- | --- | --- | --- | --- | --- | --- | --- | --- | --- | --- |
| 105 | 2.3.2.15 | **Trigger Algorithm** |  | 140d | 2019-06-03 | 2019-12-13 |  | 2019-01-07 | 2019-07-19 | 0d |  |  |  |
| 106 | 2.3.2.15.1 | E1 Trig Algo def/verilog/sim | manual | 40d | 2019-06-03 | 2019-07-26 |  | 2019-06-03 | 2019-07-26 | 0d |  |  | 5.7 wk |
| 107 | 2.3.2.15.2 | E1 Trig Algo Block Level | manual | 10d | 2019-07-29 | 2019-08-09 | 106 | 2019-07-29 | 2019-08-09 | 0d |  |  | 0.3 wk |
| 108 | 2.3.2.15.3 | E1 Trig Algo Chip Level | manual | 10d | 2019-08-12 | 2019-08-23 | 107 | 2019-08-12 | 2019-08-23 | 0d |  |  | <5.2 wk |
| 109 | 2.3.2.16 | **Top Level** |  | 145d | 2019-06-03 | 2019-12-20 |  | 2019-01-07 | 2019-07-26 | 0d |  |  |  |
| 110 | 2.3.2.16.1 | E1 Top def/verilog/sim | manual | 45d | 2019-06-03 | 2019-08-02 |  | 2019-06-03 | 2019-08-02 | 0d |  |  | 2 wk |
| 111 | 2.3.2.16.2 | E1 Top Block Level | manual | 10d | 2019-08-05 | 2019-08-16 | 110 | 2019-08-05 | 2019-08-16 | 0d |  |  | 8 wk |
| 112 | 2.3.2.16.3 | E1 Top Chip Level | manual | 10d | 2019-08-16 | 2019-08-29 | 111 | 2019-08-16 | 2019-08-29 | 0d |  |  |  |
| 113 | 2.3.2.17 | E1 Power Integrity Study | manual | 30d | 2019-01-14 | 2019-02-22 | 53 | 2019-01-14 | 2019-02-22 | 0d |  |  |  |
| 114 | 2.3.2.18 | E1 Package design | manual | 150d | 2018-09-24 | 2019-04-19 | 56 | 2018-09-24 | 2019-04-19 | 0d | P. Rubinov [25%] | 300h | Done? |
| 115 | 2.3.2.19 | System Level UVM | manual | 105d | 2020-01-06 | 2020-05-29 |  | 2020-01-06 | 2020-05-29 | 0d |  |  |  |
| 116 | 2.3.2.20 | E1 Chip Power Integrity | manual | 30d | 2019-07-29 | 2019-09-06 |  | 2019-07-29 | 2019-09-06 | 0d |  |  | Remove? |
| 117 | 2.3.3 | ECON 1 Submission | milestone, manual | 0d | 2020-06-01 | 2020-06-01 |  | 2020-06-01 | 2020-06-01 | 0d |  |  |  |
| 118 | 2.3.4 | E1 Fab/Documentation | manual | 100d | 2020-06-01 | 2020-10-16 | 116 | 2020-06-01 | 2020-10-16 | 0d | S. Miryala [10%]; M. Hammer [20%] | 240h |  |
| 119 | 2.3.5 | E1 Gbps Link Test Setup | manual | 189d | 2020-06-01 | 2021-02-18 |  | 2020-06-01 | 2021-02-18 | 0d | J. Olsen [20%]; S. Holm [20%]; P. Klabbers [5%] | 680.4h |  |
| 120 | 2.3.6 | E1 Test PCB | manual | 189d | 2020-06-01 | 2021-02-18 |  | 2020-06-01 | 2021-02-18 | 0d | N. Moibenko [10%]; A. Dyer [10%] | 302.4h |  |
| 121 | 2.3.7 | E1 Test | manual | 64d | 2020-10-19 | 2021-01-14 | 120 | 2020-10-19 | 2021-01-14 | 0d | S. Holm [50%] | 258h |  |
| 122 | 2.3.8 | ECON V1 Complete | milestone, manual | 0d | 2021-01-04 | 2021-01-04 | 121 | 2021-01-04 | 2021-01-04 | 0d |  |  |  |
| 123 | 2.4 | ECON HGCAL Vertical Slice Test | milestone, manual | 0d | 2020-03-02 | 2020-03-02 | 118 | 2020-03-02 | 2020-03-02 | 0d |  |  |  |
| 124 | 2.5 | **ECON Prototype 2 w/Trig Algo** |  | 346d | 2019-12-06 | 2021-04-02 |  | 2019-12-06 | 2021-04-02 | 0d |  | 3480h |  |
| 125 | 2.5.1 | E2 Revise Prototype 1 | manual | 145d | 2019-12-09 | 2020-06-26 |  | 2019-12-09 | 2020-06-26 | 0d | S. Miryala [40%]; R. Wickwire [45%]; M. Hammer [45%] | 1508h |  |
| 126 | 2.5.2 | E2 Trigger Algorithm | manual | 145d | 2019-12-09 | 2020-06-26 |  | 2019-12-09 | 2020-06-26 | 0d | S. Miryala [40%]; J. Hoff [40%]; R. Wickwire [45%]; M. Hammer [45%] | 1972h |  |
| 127 | 2.5.3 | ECON 2 Submission | milestone, manual | 0d | 2020-06-29 | 2020-06-29 | 125, 126 | 2020-06-29 | 2020-06-29 | 0d |  |  |  |
| 128 | 2.5.4 | E2 Fab/Documentation | manual | 110d | 2020-06-29 | 2020-11-27 |  | 2020-06-29 | 2020-11-27 | 0d |  |  |  |
| 129 | 2.5.5 | E2 Test | manual | 90d | 2020-11-30 | 2021-04-02 | 128 | 2020-11-30 | 2021-04-02 | 0d |  |  |  |
| 130 | 2.5.6 | ECON HGCAL Final Vertical Slice Test | milestone, manual | 0d | 2021-01-04 | 2021-01-04 | 127 | 2021-01-04 | 2021-01-04 | 0d |  |  |  |

| ID | WBS | Task | Type | Duration | Start | Finish | Predecessors | Complete | Remaining | Actual start | Baseline start | Baseline finish | Baseline duration | Total slack | Resources | Work | Actual work | FTE | Comment |
| --- | --- | --- | --- | --- | --- | --- | --- | --- | --- | --- | --- | --- | --- | --- | --- | --- | --- | --- | --- |
| 131 | 2.6 | **ECON Production** |  | 260d | 2020-11-30 | 2021-11-26 |  |  |  |  | 2020-11-30 | 2021-11-26 | 0d |  |  | 1496h |  |  |  |
| 132 | 2.6.1 | ECON Prod Revise Prototype 2 | manual | 85d | 2020-11-30 | 2021-03-26 |  |  |  |  | 2020-11-30 | 2021-03-26 | 0d |  | S. Miryala [20%]; J. Hoff [20%]; R. Wickwire [90%]; M. Hammer [90%] | 1496h |  |  |  |
| 133 | 2.6.2 | ECON Production Submission | milestone, manual | 0d | 2021-05-17 | 2021-05-17 | 132 |  |  |  | 2021-05-17 | 2021-05-17 | 0d |  |  |  |  |  |  |
| 134 | 2.6.3 | ECON Prod Fab | manual | 110d | 2021-03-29 | 2021-08-27 |  |  |  |  | 2021-03-29 | 2021-08-27 | 0d |  |  |  |  |  |  |
| 135 | 2.6.4 | ECON Prod Test | manual | 65d | 2021-08-30 | 2021-11-26 |  |  |  |  | 2021-08-30 | 2021-11-26 | 0d |  |  |  |  |  |  |
| 136 | 2.6.5 | ECON Motherboard Procution | milestone, manual | 0d | 2021-10-11 | 2021-10-11 | 134, 135 |  |  |  | 2021-10-11 | 2021-10-11 | 0d |  |  |  |  |  |  |
| 138 | 3 | **ETL ASIC Fast Timing (CMS)** |  | 1131d? | 2018-10-01 | 2023-01-30 |  |  |  |  | 2018-10-01 | 2023-01-30 | 0d |  |  | 344h |  | 8.5 |  |
| 139 | 3.1 | ETL ASIC FT CFD Algo Study | manual | 86d | 2019-05-24 | 2019-09-20 |  |  |  |  | 2019-05-24 | 2019-09-20 | 0d |  | T. Zimmerman [50%] | 344h |  |  |  |
| 140 | 4 | **ETROC FNAL** |  | 1175d | 2018-10-01 A | 2023-03-31 |  | 7% | 1091.05d |  | 2018-10-01 | 2022-08-30 |  | 0d |  | 16972.4h | 2016h |  |  |
| 141 | 4.1 | ETL Electronics and Firmware | manual | 524d | 2018-10-01 | 2020-10-01 |  |  |  |  | 2018-10-01 | 2020-10-01 | 0d |  | J. Olsen [70%] | 2934.4h |  |  |  |
| 142 | 4.2 | **ETROC FNAL Prototype 1 (4x4)** |  | 241d | 2018-11-30 | 2019-11-01 |  | 34% | 159.76d | 2019-01-07 | 2018-11-30 | 2019-11-01 | 0d |  |  | 2728h | 2016h |  |  |
| 143 | 4.2.1 | ETROC P1 Design | manual | 168d | 2019-01-07 A | 2019-08-28 A |  | 100% |  |  | 2019-01-07 | 2019-05-03 | 0d |  | T. Zimmerman [10%]; Q. Sun [90%]; G. Deptuch [10%]; S. Miryala [25%] | 2016h | 2016h |  |  |
| 144 | 4.2.2 | ETROC Prototype 1 Submission | milestone, manual | 0d | 2019-08-28 A | 2019-08-28 A | 143 | 100% |  |  | 2019-08-28 | 2019-08-28 | 0d |  |  |  |  |  |  |
| 145 | 4.2.3 | ETROC P1 Fab | manual | 65d | 2019-08-28 A | 2019-11-26 | 144 | 5% | 61.75d |  | 2019-08-28 | 2019-11-26 | 0d |  |  |  |  |  |  |
| 146 | 4.2.4 | ETROC P1 Prep time meas. Infrastruct. | manual | 150d | 2019-05-06 | 2019-11-29 |  |  |  |  | 2019-05-06 | 2019-11-29 | 0d |  | S. Holm [10%]; J. Wu [20%] | 360h |  |  |  |
| 147 | 4.2.5 | ETROC P1 Test PCB | manual | 60d | 2019-09-02 | 2019-11-22 |  |  |  |  | 2019-09-02 | 2019-11-22 | 0d |  | S. Holm [20%]; N. Moibenko [10%] | 144h |  |  |  |
| 148 | 4.2.6 | ETROC P1 Test | manual | 65d | 2019-11-25 | 2020-02-21 | 145 |  |  |  | 2019-11-25 | 2020-02-21 | 0d |  | S. Holm [20%]; L. DalMonte [20%] | 208h |  |  |  |
| 149 | 4.2.7 | ETROC P1 Beam Tests | milestone, manual | 0d | 2020-01-06 | 2020-01-06 | 145 |  |  |  | 2019-09-16 | 2019-09-16 | 0d |  |  |  |  |  |  |
| 150 | 4.3 | **ETROC Prototype 2 (8x8)** |  | 390d | 2020-01-06 | 2021-07-02 |  |  |  |  | 2020-01-06 | 2020-10-30 | 0d |  |  | 4888h |  |  | 2.5fte |
| 151 | 4.3.1 | ETROC P2 Design | manual | 260d | 2020-01-06 | 2021-01-01 | 148 |  |  |  | 2020-01-06 | 2021-01-01 | 0d |  | T. Zimmerman [30%]; Q. Sun [90%]; S. Miryala [30%]; J. Hoff [25%] | 3640h |  |  |  |
| 152 | 4.3.2 | ETROC P2 Auxiliary blocks | manual | 260d | 2020-01-06 | 2021-01-01 |  |  |  |  | 2020-01-06 | 2021-01-01 | 0d |  | A. Shenai [40%] | 832h |  |  |  |
| 153 | 4.3.3 | ETROC Prototype 2 Submission | milestone, manual | 0d | 2021-01-04 | 2021-01-04 | 151, 152 |  |  |  | 2020-05-04 | 2021-01-04 | 0d |  |  |  |  |  |  |
| 154 | 4.3.4 | ETROC P2 Fab | manual | 65d | 2021-01-04 | 2021-04-02 | 153 |  |  |  | 2021-01-04 | 2021-04-02 | 0d |  |  |  |  |  |  |
| 155 | 4.3.5 | ETROC P2 Test PCB | manual | 65d | 2021-01-04 | 2021-04-02 |  |  |  |  | 2021-01-04 | 2021-04-02 | 0d |  | S. Holm [20%]; N. Moibenko [20%] | 208h |  |  |  |
| 156 | 4.3.6 | ETROC P2 Test | manual | 65d | 2021-04-05 | 2021-07-02 | 154 |  |  |  | 2021-04-05 | 2021-07-02 | 0d |  | L. DalMonte [20%]; S. Holm [20%] | 208h |  |  |  |
| 157 | 4.4 | ETROC 2 Test Beam and Prototype Module | milestone, manual | 0d | 2022-05-16 | 2022-05-16 | 154 |  |  |  | 2021-09-13 | 2021-09-13 | 0d |  |  |  |  |  |  |

| ID | WBS | Task | Type | Duration | Start | Finish | Predecessors | Complete | Remaining | Actual start | Baseline start | Baseline finish | Baseline duration | Resources | Work | Actual work | FTE | Comment |
| --- | --- | --- | --- | --- | --- | --- | --- | --- | --- | --- | --- | --- | --- | --- | --- | --- | --- | --- |
| 158 | 4.5 | **ETROC Full Chip (Prototype 3 16x16)** |  | 585d | 2021-01-04 | 2023-03-31 |  |  |  |  | 2021-01-04 | 2023-03-31 | 0d |  | 6422h |  |  |  |
| 159 | 4.5.1 | ETROC Final Design | manual | 455d | 2021-01-04 | 2022-09-30 | 156, 152 |  |  |  | 2021-01-04 | 2022-09-30 | 0d | F. Fahim [40%]; T. Zimmerman [20%]; Q. Sun [90%]; R. Wickwire [15%] | 6006h |  |  |  |
| 160 | 4.5.2 | ETROC Submission | milestone, manual | 0d | 2022-09-30 | 2022-09-30 | 159 |  |  |  | 2022-09-30 | 2022-09-30 | 0d |  |  |  |  |  |
| 161 | 4.5.3 | ETROC Final Fab | manual | 65d | 2022-10-03 | 2022-12-30 | 160 |  |  |  | 2022-10-03 | 2022-12-30 | 0d |  |  |  |  |  |
| 162 | 4.5.4 | ETROC Final Test PCB | manual | 65d | 2022-10-03 | 2022-12-30 |  |  |  |  | 2022-10-03 | 2022-12-30 | 0d | S. Holm [20%]; N. Moibenko [20%] | 208h |  |  |  |
| 163 | 4.5.5 | ETROC Final Test | manual | 65d | 2023-01-02 | 2023-03-31 | 161 |  |  |  | 2023-01-02 | 2023-03-31 | 0d | S. Holm [20%]; L. DalMonte [20%] | 208h |  |  |  |
| 164 | 4.5.6 | ETROC Final Vertical Slice Test | milestone, manual | 0d | 2023-02-13 | 2023-02-13 | 161 |  |  |  | 2023-02-13 | 2023-02-12 | 0d |  |  |  |  |  |
| 166 | 5 | **NECQST (Quantum)** |  | 651d? | 2018-09-01 | 2021-02-26 |  |  | 651d? | 2018-10-01 | 2018-09-01 | 2021-02-26 | 0d |  | 1387.76h |  | 0.8 |  |
| 167 | 5.1 | Begin | milestone, manual | 0d | 2019-02-03 A | 2019-02-03 A |  | 100% |  |  |  |  |  |  |  |  |  |  |
| 168 | 5.2 | Identify test devices | manual | 20d | 2019-02-04 | 2019-03-01 | 167 |  |  |  | 2019-02-04 | 2019-03-01 | 0d |  |  |  |  |  |
| 169 | 5.3 | Cryo Testbed Commissioning | manual | 40d | 2019-02-04 | 2019-03-29 | 167 |  |  |  | 2019-02-04 | 2019-03-29 | 0d |  |  |  |  |  |
| 170 | 5.4 | Cryo Measurements | manual | 65d | 2019-03-04 | 2019-05-31 | 168 |  |  |  | 2019-03-04 | 2019-05-31 | 0d | D. Braga [30%] | 156h |  |  | Move to later? |
| 171 | 5.5 | HBT Cryo Models (4K) | manual | 64d | 2019-04-01 | 2019-06-27 | 169 |  |  |  | 2019-04-01 | 2019-06-28 | 0d | D. Braga [35%] | 184.8h |  |  | Removed Sandeep |
| 172 | 5.6 | HBT Cryo Models (4K) Review | milestone, manual | 0d | 2019-06-28 | 2019-06-28 | 171 |  |  |  |  |  |  |  |  |  |  |  |
| 173 | 5.7 | Define Specifications (JPL/CalTech) | manual | 40d | 2019-02-04 | 2019-03-29 | 167 |  |  |  | 2019-02-04 | 2019-03-29 | 0d |  |  |  |  |  |
| 174 | 5.8 | Define Architechture (GT) | manual | 65d | 2019-03-04 | 2019-05-31 | 167 |  |  |  | 2019-03-04 | 2019-05-31 | 0d |  |  |  |  |  |
| 175 | 5.9 | Design | manual | 155d | 2019-07-01 | 2020-01-31 | 172 |  |  |  | 2019-04-29 | 2019-11-29 | 0d | D. Braga [30%] | 372h |  |  | Move to later? |
| 176 | 5.10 | Intermediate Design Review | milestone, manual | 0d | 2019-08-16 | 2019-08-16 |  |  |  |  | 2019-08-16 | 2019-08-16 | 0d |  |  |  |  |  |
| 177 | 5.11 | Final Design Review | milestone, manual | 0d | 2019-10-18 | 2019-10-18 | 175 |  |  |  | 2019-10-18 | 2019-10-18 | 0d |  |  |  |  |  |
| 178 | 5.12 | Tape Out | milestone, manual | 0d | 2019-11-22 | 2019-11-22 | 177 |  |  |  | 2019-11-22 | 2019-11-22 | 0d |  |  |  |  |  |
| 179 | 5.13 | Fab | manual | 176d | 2019-12-01 | 2020-07-31 | 178 |  |  |  | 2019-12-01 | 2020-07-31 | 0d |  |  |  |  |  |
| 180 | 5.14 | 1-Year Project Report | milestone, manual | 0d | 2019-12-20 | 2019-12-20 | 178 |  |  |  | 2019-12-20 | 2019-12-20 | 0d |  |  |  |  |  |
| 181 | 5.15 | Test PCB / Packaging? | manual | 65d | 2020-03-02 | 2020-05-29 |  |  |  |  | 2020-03-02 | 2020-05-29 | 0d | N. Moibenko [5%] | 26h |  |  |  |
| 182 | 5.16 | Chip Testing | manual | 40d | 2020-08-03 | 2020-09-25 | 179 |  |  |  | 2020-08-03 | 2020-09-25 | 0d | Student 1 [50%]; P. Klabbers [5%] | 176h |  |  |  |
| 183 | 5.17 | 2-Year Project Report | milestone, manual | 0d | 2020-12-25 | 2020-12-25 |  |  |  |  | 2020-12-25 | 2020-12-25 | 0d |  |  |  |  |  |
| 184 | 5.18 | Publication of Results | manual | 40d | 2021-01-04 | 2021-02-26 |  |  |  |  | 2021-01-04 | 2021-02-26 | 0d | D. Braga [30%] | 96h |  |  |  |
| 185 | 5.19 | Cryo Setup Maintenance | manual | 589d | 2018-10-01 | 2020-12-31 |  |  |  |  | 2018-10-01 | 2020-12-31 | 0d | A. Dyer [8%] | 376.96h |  |  |  |
| 187 | 6 | Quantum Initiative | manual | 261d | 2019-01-01 | 2019-12-31 |  |  |  |  | 2019-01-01 | 2019-12-31 | 0d | D. Braga [5%] | 104.4h |  |  |  |
| 189 | 7 | RD53 | manual | 143d | 2018-05-24 A | 2018-12-10 A |  | 100% |  |  | 2018-05-24 | 2018-12-10 | 0d | S. Miryala [50%] | 572h | 572h | 0.3 | Complete |
| 190 | 8 | RD53 2019 | manual | 261d | 2019-01-01 A | 2019-12-31 |  | 75% | 65.25d |  | 2019-01-01 | 2019-12-31 | 0d | S. Miryala [20%]; N. Moibenko [5%]; P. Klabbers [20%]; L. DalMonte [20%] | 1357.2h | 1017.9h | 0.2 | Added Lou, Pam |

| ID | WBS | Task | Type | Duration | Start | Finish | Predecessors | Complete | Remaining | Actual start | Baseline start | Baseline finish | Baseline duration | Resources | Work | Actual work | FTE | Comment |
| --- | --- | --- | --- | --- | --- | --- | --- | --- | --- | --- | --- | --- | --- | --- | --- | --- | --- | --- |
| 192 | 9 | **VIPRAM** |  | 346d | 2018-09-01 | 2019-12-27 |  | 26% | 256.23d | 2018-09-03 | 2018-09-01 | 2019-01-30 | 0d |  | 507.2h | 76.8h | 0.5 | Extend to Dec '19 |
| 193 | 9.1 | Bump bonding | manual | 260d | 2018-09-03 A | 2019-08-30 |  | 20% | 208d |  | 2018-09-03 | 2018-11-01 | 0d | G. Deptuch [5%]; P. Klabbers [5%] | 208h | 41.6h |  |  |
| 194 | 9.2 | Test PCB | manual | 44d | 2018-09-03 A | 2018-11-01 A |  | 100% |  |  | 2018-09-03 | 2018-11-01 | 0d | J. Olsen [10%] | 35.2h | 35.2h |  | Completed |
| 195 | 9.3 | Test | manual | 66d | 2018-11-02 | 2019-02-01 | 194, 193 |  |  |  | 2018-10-31 | 2019-01-30 | 0d | Student 3 [50%] | 264h |  |  |  |
| 197 | 10 | **VIPIC-L & High-Density Interconnects** |  | 239d | 2018-11-01 | 2019-10-01 |  |  |  |  | 2018-11-01 | 2019-10-01 | 0d |  | 498h |  | 0.2 |  |
| 198 | 10.1 | Testing of VIPIC-L | manual | 66d | 2018-11-01 | 2019-01-31 |  |  |  |  | 2018-11-01 | 2019-01-31 | 0d | S. Holm [30%]; G. Deptuch [10%] | 211.2h |  |  |  |
| 199 | 10.2 | HD Interconnects with MIT LL | manual | 239d | 2018-11-01 | 2019-10-01 |  |  |  |  | 2018-11-01 | 2019-10-01 | 0d | G. Deptuch [10%]; P. Klabbers [5%] | 286.8h |  |  | Extend to Dec '19 |
| 200 | 11 | FCP130/iFCP65 | manual | 261d | 2018-01-01 A | 2018-12-31 A |  | 100% |  |  | 2018-01-01 | 2018-12-31 | 0d | L. DalMonte [40%] | 835.2h | 835.2h | 0.4 | Complete? |
| 201 | 12 | **FLORA** |  | 699d | 2018-05-01 A | 2021-01-01 |  | 20% | 558.35d |  | 2018-05-01 | 2021-01-01 | 0d |  | 633.6h | 633.6h | 0.3 |  |
| 202 | 12.1 | Test ROIC | manual | 132d | 2018-05-01 A | 2018-10-31 A |  | 100% |  |  | 2018-05-01 | 2018-10-31 | 0d | T. Zimmerman [50%]; Student 2 [10%] | 633.6h | 633.6h |  | Complete |
| 203 | 12.2 | FLORANext (to be submitted) | manual | 524d | 2019-01-01 | 2021-01-01 |  |  |  |  | 2019-01-01 | 2021-01-01 | 0d |  |  |  |  |  |
| 204 | 13 | ASIC Group Management | manual | 1022d | 2018-10-01 | 2022-08-30 |  |  |  |  | 2018-10-01 | 2022-08-30 | 0d | G. Deptuch [20%]; J. Hoff [10%]; S. Holm [10%] | 3270.4h |  | 1.6 |  |
| 205 | 14 | ASIC Specific System Administration | manual | 1022d | 2018-10-01 | 2022-08-30 |  |  |  |  | 2018-10-01 | 2022-08-30 | 0d | A. Shenai [20%] | 1635.2h |  | 0.8 | Change to ~40% |
| 206 | 15 | ASIC Specific Infrastructure/Maintenance | manual | 1022d | 2018-10-01 | 2022-08-30 |  |  |  |  | 2018-10-01 | 2022-08-30 | 0d | A. Dyer [20%] | 1635.2h |  | 0.2 | Change %? Have extended |
| 207 | 16 | ASIC Project Support (Robot, etc.) | manual | 1022d | 2018-10-01 | 2022-08-30 |  |  |  |  | 2018-10-01 | 2022-08-30 | 0d | P. Klabbers [55%] | 4496.8h |  | 0.8 | Reduced %, extended. |
